# HE_planning

Schedule from MS Project, 2016-03-21 to 2017-05-30.
CERN

## Calendars

- Standard: Mon-Fri 08:00-12:00, 13:00-17:00; Sat-Sun off.

## Schedule

| ID | WBS | Task | Type | Duration | Start | Finish | Predecessors | Total slack | Free slack | Constraint |
| --- | --- | --- | --- | --- | --- | --- | --- | --- | --- | --- |
| 1 | 1 | **Overhead cranes** |  | 307d | 2016-03-21 | 2017-05-23 |  | 5d |  |  |
| 2 | 1.1 | Pre-study and specifications |  | 3w | 2016-03-21 | 2016-04-08 |  | 137d | 0d | start no earlier than 2016-03-21 |
| 3 | 1.2 | Offer from manufacturer | milestone | 0d | 2016-06-24 | 2016-06-24 | 2FS+11w | 137d | 0d |  |
| 4 | 1.3 | Purchase order release | milestone | 0d | 2016-07-08 | 2016-07-08 | 3FS+2w | 137d | 0d |  |
| 5 | 1.4 | Design |  | 4w | 2016-07-11 | 2016-08-05 | 4 | 137d | 0d |  |
| 6 | 1.5 | Manufacturing and workshop tests |  | 15w | 2016-08-08 | 2016-11-18 | 5 | 137d |  |  |
| 7 | 1.6 | Main hall crane: mechanical installation |  | 2d | 2016-11-24 | 2016-11-25 |  | 5d | 0d | start no earlier than 2016-11-24 |
| 8 | 1.7 | Main hall crane: feeding line and commissioning |  | 10d | 2017-05-01 | 2017-05-12 | 7FS+22w | 5d | 0d |  |
| 9 | 1.8 | Lab crane installation |  | 1w | 2017-05-15 | 2017-05-19 | 8 | 5d | 0d |  |
| 10 | 1.9 | Acceptance tests at CERN |  | 2d | 2017-05-22 | 2017-05-23 | 9 | 5d |  |  |
| 11 | 2 | **Lift** |  | 285d | 2016-04-27 | 2017-05-30 |  | 0d |  |  |
| 12 | 2.1 | Pre-study and specifications |  | 9w | 2016-04-27 | 2016-06-28 |  | 0d |  | start no earlier than 2016-04-27 |
| 13 | 2.2 | Offer from manufacturer | milestone | 0d | 2016-07-27 | 2016-07-27 | 12FS+21d | 0d |  |  |
| 14 | 2.3 | Purchase order release | milestone | 0d | 2016-08-16 | 2016-08-16 | 13FS+14d | 0d |  |  |
| 15 | 2.4 | Design |  | 2mo | 2016-08-17 | 2016-10-11 | 14 | 0d |  |  |
| 16 | 2.5 | Manufacturing and workshop tests |  | 5mo | 2016-10-12 | 2017-02-28 | 15 | 0d |  |  |
| 17 | 2.6 | Lift installation |  | 3mo | 2017-03-01 | 2017-05-23 | 16 | 0d |  |  |
| 18 | 2.7 | Acceptance tests at CERN |  | 5d | 2017-05-24 | 2017-05-30 | 17 | 0d |  | finish no earlier than 2016-09-30 |
